# Peoject-1

Schedule from Primavera P6, 2017-05-06 to 2018-03-02, data date 2017-05-06, A marks actual dates.

## Calendars

- 7-Day Workweek: Mon-Sun 08:00-16:00.

## Schedule

| ID | WBS | Activity | Type | Duration | Start | Finish | Predecessors | Complete | Planned start | Planned finish | Total float | Free float | Constraint |
| --- | --- | --- | --- | --- | --- | --- | --- | --- | --- | --- | --- | --- | --- |
|  | 1 | **Milestones** |  |  | 2017-05-06 | 2017-05-25 |  |  |  |  |  |  |  |
| A1000 |  | LOI Date | milestone | 0d | 2017-05-06 | 2017-05-06 |  |  |  |  | 365d |  |  |
| A1005 |  | Effective Date | milestone | 0d | 2017-05-06 A | 2017-05-06 A |  | 100% |  |  |  |  | start on or after 2018-05-06 |
| A1010 |  | Bank Garanty Payment Date | milestone | 0d | 2017-05-20 A | 2017-05-20 A |  | 100% | 2017-10-20 | 2017-10-20 |  |  |  |
| A1020 |  | Advanced Payment Date | milestone | 0d | 2017-05-25 | 2017-05-25 |  |  |  |  | 346d |  | start on or after 2017-05-25 |
|  | 2 | **Engineering** |  |  | 2017-05-06 | 2017-07-24 |  |  |  |  |  |  |  |
|  | 1 | **Critical Doc.** |  |  | 2017-05-06 | 2017-07-24 |  |  |  |  |  |  |  |
| A8550 |  | Inspectin Test Plan |  | 22d | 2017-05-06 | 2017-05-27 |  |  |  |  | 343d |  |  |
| A8560 |  | Welding Book |  | 40d | 2017-05-06 | 2017-06-14 |  |  |  |  | 64d | 0d |  |
| A8580 |  | Other Critical Documents should be mentioned |  | 80d | 2017-05-06 | 2017-07-24 |  |  |  |  | 285d |  |  |
| A8570 |  | Hydro Test Procedure |  | 20d | 2017-06-15 | 2017-07-04 | A8560 |  |  |  | 64d | 0d |  |
|  | 2 | **None Critical Doc.** |  |  | 2017-05-06 | 2017-07-14 |  |  |  |  |  |  |  |
| A8590 |  | Document 1 |  | 30d | 2017-05-06 | 2017-06-04 |  |  |  |  | 295d | 0d |  |
| A8600 |  | Document 2 |  | 20d | 2017-06-05 | 2017-06-24 | A8590 |  |  |  | 295d | 0d |  |
| A8610 |  | Document 3 |  | 20d | 2017-06-25 | 2017-07-14 | A8600 |  |  |  | 295d |  |  |
|  | 3 | **Supply of Material** |  |  | 2017-06-25 | 2017-10-20 |  |  |  |  |  |  |  |
|  | 7 | **Foreign Supply** |  |  | 2017-07-05 | 2017-10-20 |  |  |  |  |  |  |  |
|  | 1 | **Supply of Plates** |  |  | 2017-07-05 | 2017-10-20 |  |  |  |  |  |  |  |
| A5550 |  | Issue Purchase Order (PO) |  | 4d | 2017-07-05 | 2017-07-08 | A8570 |  |  |  | 64d | 0d |  |
| A5570 |  | Shioment/FOB/... |  | 10d | 2017-07-09 | 2017-07-18 | A5550 |  |  |  | 64d | 0d |  |
| A5580 |  | Custom Clearance |  | 8d | 2017-07-19 | 2017-07-26 | A5570 |  |  |  | 64d | 0d |  |
| A5590 |  | Transportation and delivery at site |  | 81d | 2017-07-27 | 2017-10-15 | A5580 |  |  |  | 64d | 0d |  |
| A8660 |  | Delivery to Shop |  | 5d | 2017-10-16 | 2017-10-20 | A5590, A5580, A5590 FF |  |  |  | 64d | 0d |  |
|  | 8 | **Domestic Supply** |  |  | 2017-06-25 | 2017-07-08 |  |  |  |  |  |  |  |
|  | 1 | **Supply of Pipes** |  |  | 2017-06-25 | 2017-07-08 |  |  |  |  |  |  |  |
| A5780 |  | Issue Purchase Order (PO) |  | 4d | 2017-06-25 | 2017-06-28 | A8600 |  |  |  | 301d | 0d |  |
| A5971 |  | Transportation and delivery at site |  | 10d | 2017-06-29 | 2017-07-08 | A5780 |  |  |  | 301d |  |  |

| ID | WBS | Activity | Duration | Start | Finish | Predecessors | Total float | Free float |
| --- | --- | --- | --- | --- | --- | --- | --- | --- |
|  | 4 | **Fabrication** |  | 2017-10-21 | 2018-01-15 |  |  |  |
|  | 2 | **30-TK-1801** |  | 2017-10-21 | 2018-01-15 |  |  |  |
|  | 1 | **Fabrication** |  | 2017-10-21 | 2017-12-16 |  |  |  |
| A8690 |  | Cutting & Edge Prepration Shell Plates | 8d | 2017-10-21 | 2017-10-28 | A8660 | 64d | 0d |
| A8700 |  | Rolling Shell Plates | 8d | 2017-10-29 | 2017-11-05 | A8690 | 81d | 0d |
| A8750 |  | Cutting & Beveling Shell Plate Skirt | 8d | 2017-10-29 | 2017-11-05 | A8690 | 64d | 0d |
| A8710 |  | Assy. & Welding Shell Plates | 10d | 2017-11-06 | 2017-11-15 | A8700 | 81d | 0d |
| A8760 |  | Rolling Shell Plate Skirt | 8d | 2017-11-06 | 2017-11-13 | A8750 | 64d | 0d |
| A8770 |  | Assy. & Welding Skirt | 20d | 2017-11-14 | 2017-12-03 | A8760 | 64d | 0d |
| A8720 |  | Assy. & Welding Shell Plate to Head I | 4d | 2017-11-16 | 2017-11-19 | A8710 | 81d | 0d |
| A8730 |  | Assy. & Welding Shell Plate to Head II | 4d | 2017-11-20 | 2017-11-23 | A8720 | 153d | 0d |
| A8740 |  | Assy. & Welding Accessories | 14d | 2017-11-20 | 2017-12-03 | A8720 | 133d | 39d |
| A8810 |  | Assy. & Welding Flanges | 10d | 2017-11-24 | 2017-12-03 | A8730 | 153d |  |
| A8780 |  | Assy. & Welding Base & Top Ring to Skirt | 6d | 2017-12-01 | 2017-12-06 | A8770 FF+3d | 64d | 0d |
| A8790 |  | Assy. Skirt to Head | 5d | 2017-12-07 | 2017-12-11 | A8780, A8720 | 64d | 0d |
| A8800 |  | Welding Skirt to Head | 5d | 2017-12-12 | 2017-12-16 | A8790 | 90d | 26d |
|  | 3 | **Test** |  | 2017-12-12 | 2018-01-15 |  |  |  |
| A8820 |  | PT, RT & Etc. | 31d | 2017-12-12 | 2018-01-11 | A8660, A8790 | 64d | 0d |
| A8830 |  | PWHT | 6d | 2018-01-03 | 2018-01-09 | A8820 FF-3d | 117d |  |
| A8840 |  | Hydro Test | 4d | 2018-01-12 | 2018-01-15 | A8820 | 110d |  |
|  | 2 | **Blasting & Painting** |  | 2017-12-12 | 2017-12-17 |  |  |  |
| A8850 |  | Blasting 30-D-1801 | 4d | 2017-12-12 | 2017-12-15 | A8660, A8790 | 89d | 0d |
| A8860 |  | Painting 30-D-1801 | 2d | 2017-12-16 | 2017-12-17 | A8850 | 89d | 25d |
|  | 6 | **Ex-Work and Transportation** |  | 2018-01-12 | 2018-02-20 |  |  |  |
|  | 1 | **Onshore** |  | 2018-01-12 | 2018-01-21 |  |  |  |
| A8870 |  | shipment | 5d | 2018-01-12 | 2018-01-16 | A8860, A8740, A8820 | 94d | 0d |
| A8880 |  | delivery to site | 5d | 2018-01-17 | 2018-01-21 | A8870 | 94d | 30d |

| ID | WBS | Activity | Duration | Start | Finish | Predecessors | Total float | Free float |
| --- | --- | --- | --- | --- | --- | --- | --- | --- |
|  | 2 | **Offshore** |  | 2018-01-12 | 2018-02-20 |  |  |  |
| A8890 |  | Shipment/FOB | 30d | 2018-01-12 | 2018-02-10 | A8860, A8790, A8800, A8820 | 64d | 0d |
| A8900 |  | Custom Vlearance | 5d | 2018-02-11 | 2018-02-15 | A8890 | 64d | 0d |
| A8910 |  | Shipment delivery to site | 5d | 2018-02-16 | 2018-02-20 | A8900, A8900 FF | 64d | 0d |
|  | 7 | **Final Data Book** |  | 2018-02-21 | 2018-03-02 |  |  |  |
| A8400 |  | Final Data Book | 10d | 2018-02-21 | 2018-03-02 | A8880, A8910 | 64d |  |
